# MSP_CCPM

Schedule from MS Project, 2015-10-16 to 2015-12-25, status date 2015-06-27, scheduled back from the finish.

## Calendars

- CMPM PMS_5D_8H: Mon-Fri 08:00-16:00; Sat-Sun off. Exceptions (off unless hours are given): 2015-11-26 (Thanksgiving), 2015-11-27 (Holiday), 2015-12-25 (Christmas).

## Resources

| Resource |
| --- |
| Purchasing |
| Dk Red |
| Orange |
| Purple |
| Lt Blue |
| Lt Green |
| Finish |
| Buffer |

## Schedule

| ID | Task | Type | Duration | Start | Finish | Predecessors | Total slack | Free slack | Constraint | Resources | Work | Buffer Calculations |
| --- | --- | --- | --- | --- | --- | --- | --- | --- | --- | --- | --- | --- |
| 1 | Material A |  | 1d | 2015-10-16 | 2015-10-16 |  | 0d |  | as late as possible | Purchasing | 8h |  |
| 2 | Material B |  | 1d | 2015-10-22 | 2015-10-22 |  | 4d | 0d | as late as possible | Purchasing | 8h |  |
| 3 | Process B1 |  | 5d | 2015-10-23 | 2015-10-29 | 2 | 4d | 0d | as late as possible | Orange | 40h |  |
| 4 | Process B2 |  | 3d | 2015-10-30 | 2015-11-03 | 3 | 4d | 0d | as late as possible | Purple | 24h |  |
| 5 | Process B3 |  | 3d | 2015-11-04 | 2015-11-06 | 4 | 4d | 0d | as late as possible | Purple | 24h |  |
| 6 | Process A1 |  | 4d | 2015-10-19 | 2015-10-22 | 1 | 0d |  | as late as possible | Dk Red | 32h |  |
| 7 | Process A2 |  | 3d | 2015-10-23 | 2015-10-27 | 6 | 0d |  | as late as possible | Orange | 24h |  |
| 8 | Process A3 |  | 8d | 2015-10-28 | 2015-11-06 | 7 | 0d |  | as late as possible | Purple | 64h |  |
| 9 | Assembly A5 |  | 27d | 2015-11-09 | 2015-12-17 | 5, 8 | 0d |  | as late as possible | Lt Green | 216h |  |
| 10 | Process A9 |  | 5d | 2015-12-18 | 2015-12-24 | 9 | 0d |  | as late as possible | Lt Blue | 40h |  |
| 11 | CC Complete | milestone | 0d | 2015-12-25 | 2015-12-25 | 10 | 0d |  | as late as possible | Finish |  |  |
| 12 | Project Buffer | milestone | 0d | 2015-12-25 | 2015-12-25 | 11 | 0d |  | finish no later than 2015-12-25 | Buffer |  | 100.0 Percent of Safety Removed + 0d |
